# Proton Source Upgrade

Schedule from MS Project, 2011-01-05 to 2014-01-03, costs in $.
Fermi National Accelerator Laboratory

## Calendars

- Standard: Mon-Fri 08:00-12:00, 13:00-17:00; Sat-Sun off.

## Resources

| Resource | Group | Rate |
| --- | --- | --- |
| Accounting Clerical | Finance | 69.3 |
| Operations Finance | Finance | 129.78 |
| Administrative Support (monthly) | Other Administration | 85.5 |
| Administrative Support (weekly) | Other Administration | 56.71 |
| Procurement (monthly) | Procurement | 85.79 |
| Procurement (weekly) | Procurement | 79.1 |
| Training | Communications | 105.16 |
| Accounting-Accountant | Finance | 79.45 |
| Project Controls | Project Management | 130.41 |
| Project Manager | Project Management | 141.08 |
| Construction Safety | ES&H | 155.06 |
| Environmental | ES&H | 152.61 |
| Industrial Hygienist | ES&H | 84.24 |
| Radiation Protection (monthly) | ES&H | 112.64 |
| Radiation Protection (weekly) | ES&H | 70.91 |
| Safety (monthly) | ES&H | 109.76 |
| Safety (weekly) | ES&H | 65.2 |
| Control System Engineer (monthly) | Electrical Engineer | 127.01 |
| Control System Engineer (weekly) | Electrical Engineer | 113.13 |
| Electrical Design Engineer | Electrical Engineer | 113.08 |
| Electronics Design Engineer | Electrical Engineer | 130.73 |
| Interlock Engineer | Electrical Engineer | 120.86 |
| RF Design Engineer | Electrical Engineer | 122.84 |
| Cryogenics Engineer | Mechanical Engineer | 119.43 |
| Mechanical Analysis Engineer | Mechanical Engineer | 120.56 |
| Mechanical Design Engineer (monthly) | Mechanical Engineer | 115.81 |
| Mechanical Design Engineer (weekly) | Mechanical Engineer | 94.46 |
| Mechanical Technical Manager | Mechanical Engineer | 162 |
| Process/Controls Engineer | Mechanical Engineer | 104.41 |
| Process/Controls Engineer | Mechanical Engineer | 101.13 |
| Construction Coordinator | Facilities Management | 107.36 |
| Facilities Management | Facilities Management | 100.36 |
| Applications Development & Systems Analyst (monthly) | Information Technology | 119.79 |
| Applications Development & Systems Analyst (weekly) | Information Technology | 76.82 |
| Computer Customer Support (monthly) | Information Technology | 102.75 |
| Computer Customer Support (weekly) | Information Technology | 69.96 |
| Computer Security Analyst | Information Technology | 139.7 |
| Computing Services Specialist | Information Technology | 138.67 |
| Database Administration Analyst | Information Technology | 121.41 |
| Network Analyst | Information Technology | 117.12 |
| PC Support Associate (monthly) | Information Technology | 83.66 |
| PC Support Associate (weekly) | Information Technology | 62.72 |
| Systems Administrator | Information Technology | 99.32 |
| Web Applications Developer | Information Technology | 122.49 |
| Accelerator Physicist Experimental | Scientist | 138.3 |
| Accelerator Physicist Theory | Scientist | 143.25 |
| Magnet Scientist | Scientist | 135.87 |
| Particle Physicist Experimental | Scientist | 152.81 |
| RF Scientist | Scientist | 170.57 |
| Cryo Designer (monthly) | Design | 104.62 |
| Cryo Designer (weekly) | Design | 71.02 |
| Electrical Designer (monthly) | Design | 113.33 |
| Electrical Designer (weekly) | Design | 80.53 |
| Mechanical Designer (monthly) | Design | 110.36 |
| Mechanical Designer (weekly) | Design | 80.12 |
| Mechanical Drafter | Design | 61.33 |
| Electrical Assembly Technician | Electrical Technician | 54.03 |
| Electrical Interlock Technician (monthly) | Electrical Technician | 117.34 |
| Electrical Interlock Technician (weekly) | Electrical Technician | 85.78 |
| Electrical Task Manager | Electrical Technician | 105.73 |
| Electrical Technician | Electrical Technician | 74.91 |
| Electrical Technician Supervisor (monthly) | Electrical Technician | 113.16 |
| Electrical Technician Supervisor (weekly) | Electrical Technician | 113.57 |
| Electronics Technician | Electrical Technician | 109.41 |
| Electronics Technician | Electrical Technician | 77.29 |
| Cryo Technician | Mechanical Technician | 67.17 |
| High Vac Technician | Mechanical Technician | 74.89 |
| Mechanical Assembly Technician | Mechanical Technician | 65.25 |
| Mechanical SRF Technician | Mechanical Technician | 55.42 |
| Mechanical Systems Technician | Mechanical Technician | 65.55 |
| Mechanical Task Manager | Mechanical Technician | 62.47 |
| Mechanical Technician Supervisor (monthly) | Mechanical Technician | 109.29 |
| Mechanical Technician Supervisor (weekly) | Mechanical Technician | 89.66 |
| Accelerator Operator (monthly) | Operations | 87.82 |
| Accelerator Operator (weekly) | Operations | 72.27 |
| Accelerator Systems Specialist | Operations | 112.3 |
| Operations Manager | Operations | 148.62 |
| Operations Specialist | Operations | 107.83 |
| Machine Shop | Shop Services | 73 |
| FESS Engineering | Shop Services | 103 |
| Electrical Drafter | Design | 61.52 |

## Schedule

| ID | WBS | Task | Type | Duration | Start | Finish | Predecessors | Total slack | Free slack | Constraint | Resources | Work | Cost |
| --- | --- | --- | --- | --- | --- | --- | --- | --- | --- | --- | --- | --- | --- |
| 1 | 1 | **PROTON SOURCE IMPROVEMENT PLAN** |  | 783d? | 2011-01-05 | 2014-01-03 |  | 0d |  |  |  | 234262h | 40,824,927.12 |
| 2 | 1.1 | **PROGRAM MANAGEMENT** |  | 747d? | 2011-01-05 | 2013-11-14 |  | 36d |  |  |  | 17928h | 2,025,146.88 |
| 3 | 1.1.1 | **PROGRAM INITIATION** |  | 1d? | 2011-01-05 | 2011-01-05 |  | 782d |  |  |  |  |  |
| 4 | 1.1.1.1 | Assign Program Technical Manager |  | 1d? | 2011-01-05 | 2011-01-05 |  | 782d |  |  |  |  |  |
| 5 | 1.1.1.2 | Assign Program Schedule, Budget and Reporting Manager |  | 1d? | 2011-01-05 | 2011-01-05 |  | 782d |  |  |  |  |  |
| 6 | 1.1.1.3 | Assign Level Two, Level Three, and Level 4 Managers |  | 1d? | 2011-01-05 | 2011-01-05 |  | 782d |  |  |  |  |  |
| 7 | 1.1.2 | **TECHNICAL MANAGEMENT ACTIVITIES** |  | 1d? | 2011-01-05 | 2011-01-05 |  | 782d |  |  |  |  |  |
| 8 | 1.1.2.1 | Establish appropriate meeting schedules |  | 1d? | 2011-01-05 | 2011-01-05 |  | 782d |  |  |  |  |  |
| 9 | 1.1.2.2 | Work with Level 4 & 5 managers to document scope of each task |  | 1d? | 2011-01-05 | 2011-01-05 |  | 782d |  |  |  |  |  |
| 10 | 1.1.3 | **PROJECT MANAGEMENT ACTIVITIES** |  | 1d? | 2011-01-05 | 2011-01-05 |  | 782d |  |  |  |  |  |
| 11 | 1.1.3.1 | Establish program management group meeting Schedule |  | 1d? | 2011-01-05 | 2011-01-05 |  | 782d |  |  |  |  |  |
| 12 | 1.1.5 | Program management labor placeholder |  | 747d | 2011-01-05 | 2013-11-14 |  | 36d |  | start no earlier than 2011-01-05 | Project Manager; Accelerator Systems Specialist; Administrative Support (monthly) | 17928h | 2,025,146.88 |
| 13 | 1.2 | **LINAC** |  | 743d? | 2011-01-05 | 2013-11-08 |  | 40d |  |  |  | 79417.7h | 14,097,970.76 |
| 14 | 1.2.3 | **200 MHz RF Power Systems** |  | 743d | 2011-01-05 | 2013-11-08 |  | 40d |  |  |  | 17953.7h | 5,819,900.38 |
| 15 | 1.2.3.5 | Develop a 7835 tube procurement schedule strategy based on simulation model |  | 40d | 2011-01-05 | 2011-03-01 |  | 503d | 206d |  | Accelerator Physicist Experimental [50%]; Accelerator Operator (weekly) | 160h | 22,128 |
| 16 | 1.2.3.6 | **Build up 7835 RF tube stock to 4 operating year supply** |  | 743d | 2011-01-05 | 2013-11-08 |  | 40d |  |  |  | 6120h | 2,936,479.2 |
| 17 | 1.2.3.6.1 | FY12 7835 tube build-up procurement |  | 30d | 2011-12-15 | 2012-01-25 | 15 | 297d | 0d | start no earlier than 2011-12-15 |  |  | 1,200,000 |
| 18 | 1.2.3.6.3 | Receive tubes from FY12 order | milestone | 0d | 2012-11-14 | 2012-11-14 | 17FS+210d | 297d |  |  |  |  |  |
| 19 | 1.2.3.6.2 | FY13 7835 tube build-up procurement |  | 30d | 2012-12-10 | 2013-01-18 |  | 40d | 0d | start no earlier than 2012-12-10 |  |  | 1,200,000 |
| 20 | 1.2.3.6.4 | Receive tubes from FY13 order | milestone | 0d | 2013-11-08 | 2013-11-08 | 19FS+210d | 40d |  |  |  |  |  |
| 21 | 1.2.3.6.5 | Process tubes (verify/check) |  | 510d | 2011-01-05 | 2012-12-18 |  | 273d |  |  | Electrical Technician; Electrical Technician Supervisor (monthly) [50%] | 6120h | 536,479.2 |
| 22 | 1.2.3.13 | Develop 400MHz Linac Concept |  | 115d | 2011-01-05 | 2011-06-14 |  | 668d |  |  | RF Design Engineer [75%]; Mechanical Design Engineer (monthly) [75%] | 1380h | 164,668.5 |
| 23 | 1.2.3.7 | **Establish MOU with LANL on joint 200 MHz RF power system development** |  | 463d | 2011-01-05 | 2012-10-15 |  | 320d |  |  |  | 534h | 265,596.56 |
| 24 | 1.2.3.7.1 | FY12 MOU payment | milestone | 0d | 2011-10-14 | 2011-10-14 |  | 581d |  | start no earlier than 2011-10-14 |  |  | 100,000 |
| 25 | 1.2.3.7.2 | FY13 MOU payment | milestone | 0d | 2012-10-15 | 2012-10-15 |  | 320d |  | start no earlier than 2012-10-15 |  |  | 100,000 |
| 26 | 1.2.3.7.3 | MOU Management |  | 445d | 2011-01-05 | 2012-09-18 |  | 338d |  |  | RF Design Engineer [15%] | 534h | 65,596.56 |

Notes:
- 22: backup for 200MHz, put labor here, EE and ME

| ID | WBS | Task | Type | Duration | Start | Finish | Predecessors | Total slack | Free slack | Constraint | Resources | Work | Cost |
| --- | --- | --- | --- | --- | --- | --- | --- | --- | --- | --- | --- | --- | --- |
| 27 | 1.2.3.9 | **Linac 200 MHz Modulators** |  | 464d | 2011-01-05 | 2012-10-15 |  | 319d |  |  |  | 9759.69h | 2,431,028.12 |
| 28 | 1.2.3.9.1 | Develop engineering specs and drawings for 200 MHz Modulator improvements |  | 141d | 2011-01-05 | 2011-07-20 |  | 480d | 61d |  | Electronics Technician [150%]; RF Design Engineer; Electrical Drafter [75%]; Electronics Design Engineer [75%] | 3927.69h | 422,399.64 |
| 29 | 1.2.3.9.2 | **Procure Modulator Renovation Components** |  | 262d | 2011-10-14 | 2012-10-15 | 28 | 319d |  |  |  |  | 1,307,000 |
| 30 | 1.2.3.9.2.1 | 200MHz modulator FY12 procurements | milestone | 0d | 2011-10-14 | 2011-10-14 |  | 581d |  | start no earlier than 2011-10-14 |  |  | 307,000 |
| 31 | 1.2.3.9.2.2 | 200MHz modulator FY13 procurements | milestone | 0d | 2012-10-15 | 2012-10-15 |  | 319d |  | finish no earlier than 2012-10-15 |  |  | 1,000,000 |
| 32 | 1.2.3.9.3 | Install and Commission Modulator Renovations |  | 162d | 2012-02-16 | 2012-09-28 | 28 | 330d |  | finish no earlier than 2012-09-28 | RF Design Engineer [150%]; Electronics Technician [200%]; Accelerator Physicist Experimental | 5832h | 701,628.48 |
| 33 | 1.2.4 | **PreAccelerator RFQ Project** |  | 508d | 2011-01-05 | 2012-12-14 |  | 275d |  |  |  | 20928h | 2,997,841.6 |
| 34 | 1.2.4.1 | Magnets | milestone | 0d | 2011-03-01 | 2011-03-01 |  | 344d | 0d | start no earlier than 2011-03-01 |  |  | 350,000 |
| 35 | 1.2.4.2 | **Fabrication and Assembly** |  | 170d | 2011-02-18 | 2011-10-14 |  | 581d |  |  |  |  | 250,000 |
| 36 | 1.2.4.2.1 | Fabrication and Assembly FY11 |  | 150d | 2011-02-18 | 2011-09-15 |  | 601d |  | finish no earlier than 2011-09-15 |  |  | 150,000 |
| 37 | 1.2.4.2.2 | Fabrication and Assembly FY12 procurement | milestone | 0d | 2011-10-14 | 2011-10-14 |  | 581d |  | start no earlier than 2011-10-14 |  |  | 100,000 |
| 38 | 1.2.4.10 | RFQ received | milestone | 0d | 2011-03-25 | 2011-03-25 |  | 446d | 102d | start no earlier than 2011-03-25 |  |  |  |
| 39 | 1.2.4.4 | **RFQ connections and cabling** |  | 110d | 2011-05-13 | 2011-10-14 |  | 581d |  |  |  |  | 110,000 |
| 40 | 1.2.4.4.1 | RFQ connections and cabling work |  | 91d | 2011-05-13 | 2011-09-16 |  | 600d |  | start no earlier than 2011-05-13 |  |  |  |
| 41 | 1.2.4.4.2 | RFQ connections and cabling procurements | milestone | 0d | 2011-10-14 | 2011-10-14 |  | 581d |  | start no earlier than 2011-10-14 |  |  | 110,000 |
| 42 | 1.2.4.9 | Ion Source Lab preops installation |  | 80d | 2011-08-16 | 2011-12-05 | 38, 34FS+120d | 344d | 0d |  |  |  |  |
| 43 | 1.2.4.3 | Simulations and Testing | milestone | 0d | 2011-10-14 | 2011-10-14 |  | 381d | 37d | start no earlier than 2011-10-14 |  |  | 40,000 |
| 44 | 1.2.4.8 | Preops in Ion Source Lab |  | 80d | 2011-12-06 | 2012-03-26 | 43, 42 | 344d | 0d |  |  |  |  |
| 45 | 1.2.4.6 | RFQ System Final Installation and Commissioning |  | 120d | 2012-03-27 | 2012-09-10 | 44 | 344d |  |  |  |  |  |
| 46 | 1.2.4.16 | RFQ Labor Placeholder |  | 436d | 2011-01-05 | 2012-09-05 |  | 347d | 72d |  | Accelerator Physicist Experimental [50%]; Operations Specialist; RF Design Engineer [75%]; Mechanical Design Engineer (monthly); Electrical Technician Supervisor (monthly) [75%]; Electronics Technician; Mechanical Assembly Technician | 20928h | 2,247,841.6 |
| 47 | 1.2.4.7 | RFQ System Operational | milestone | 0d | 2012-12-14 | 2012-12-14 | 46 | 275d |  | finish no earlier than 2012-12-14 |  |  |  |
| 48 | 1.2.13 | **Linac Controls** |  | 243d | 2012-10-15 | 2013-09-18 |  | 77d |  |  |  | 8748h | 1,625,546.84 |
| 49 | 1.2.13.1 | Linac Controls Procurement | milestone | 0d | 2012-10-15 | 2012-10-15 |  | 320d |  | start no earlier than 2012-10-15 |  |  | 500,000 |
| 50 | 1.2.13.2 | Linac Controls Labor |  | 243d | 2012-10-15 | 2013-09-18 |  | 77d |  | start no earlier than 2012-10-15 | Control System Engineer (monthly) [250%]; Electronics Design Engineer [200%] | 8748h | 1,125,546.84 |

Notes:
- 33: Viability

| ID | WBS | Task | Type | Duration | Start | Finish | Predecessors | Total slack | Free slack | Constraint | Resources | Work | Cost |
| --- | --- | --- | --- | --- | --- | --- | --- | --- | --- | --- | --- | --- | --- |
| 51 | 1.2.5 | **Linac Vacuum** |  | 275d? | 2011-01-05 | 2012-01-24 |  | 508d |  |  |  | 8800h | 931,808 |
| 52 | 1.2.5.1 | Linac Vacuum equipment order placed |  | 1d? | 2011-10-14 | 2011-10-14 |  | 580d |  | start no earlier than 2011-10-14 |  |  | 255,000 |
| 53 | 1.2.5.2 | Linac Vacuum Labor |  | 275d | 2011-01-05 | 2012-01-24 |  | 508d |  |  | Mechanical Drafter; Mechanical Design Engineer (monthly); Mechanical Assembly Technician [200%] | 8800h | 676,808 |
| 54 | 1.2.9 | Notch Creation in Linac for Booster Extraction Kicker |  | 147d | 2011-01-05 | 2011-07-28 |  | 636d |  |  | Accelerator Physicist Experimental [75%]; Electrical Design Engineer; Electrical Technician; Mechanical Systems Technician [75%] | 4116h | 400,871.94 |
| 55 | 1.2.19 | **Beam Diagnostics** |  | 267d? | 2012-10-15 | 2013-10-22 |  | 53d |  |  |  | 10640h | 1,375,350.24 |
| 56 | 1.2.19.1 | Beam Diagnostics Procurement |  | 1d? | 2012-10-15 | 2012-10-15 |  | 53d | 0d | start no earlier than 2012-10-15 |  |  | 250,000 |
| 57 | 1.2.19.2 | Beam Diagnostics Labor |  | 266d | 2012-10-16 | 2013-10-22 | 56 | 53d |  |  | Electronics Design Engineer; Electronics Technician; Mechanical Assembly Technician; Mechanical Designer (monthly); Electrical Design Engineer | 10640h | 1,125,350.24 |
| 58 | 1.2.11 | **Emittance Reduction/Control** |  | 112d | 2011-03-01 | 2011-08-03 |  | 632d |  |  |  | 2688h | 348,884.48 |
| 59 | 1.2.11.1 | Emittance Reduction/Control Labor placeholder |  | 112d | 2011-03-01 | 2011-08-03 |  | 632d |  | start no earlier than 2011-03-01 | Accelerator Physicist Experimental; Accelerator Physicist Theory; Operations Specialist | 2688h | 348,884.48 |
| 60 | 1.2.12 | **Collimation** |  | 165d | 2011-03-01 | 2011-10-17 |  | 579d |  |  |  | 5544h | 597,767.28 |
| 61 | 1.2.12.2 | Linac Collimation Labor placeholder |  | 165d | 2011-03-01 | 2011-10-17 |  | 579d |  | start no earlier than 2011-03-01 | Accelerator Physicist Experimental; Mechanical Design Engineer (monthly); Mechanical Assembly Technician; Electrical Design Engineer [60%]; Electronics Technician [60%] | 5544h | 597,767.28 |
| 62 | 1.3 | **400 MEV LINE** |  | 267d? | 2011-01-05 | 2012-01-12 |  | 516d |  |  |  | 16112h | 1,773,878.16 |
| 63 | 1.3.9 | 400 MeV Line beam optics and matching |  | 222d | 2011-01-05 | 2011-11-10 |  | 561d |  |  | Accelerator Physicist Experimental [50%]; Accelerator Physicist Theory [50%] | 1776h | 250,016.4 |
| 64 | 1.3.3 | Momentum Line Beam Dump |  | 1d? | 2011-01-05 | 2011-01-05 |  | 782d |  |  |  |  |  |
| 65 | 1.3.4 | **Beam Diagnostics and Controls** |  | 267d? | 2011-01-05 | 2012-01-12 |  | 516d |  |  |  | 10640h | 1,125,350.24 |
| 66 | 1.3.4.1 | Beam Diagnostics and Controls Procurements |  | 1d? | 2011-01-05 | 2011-01-05 |  | 516d | 0d |  |  |  |  |
| 67 | 1.3.4.2 | Beam Diagnostics and Controls Labor |  | 266d | 2011-01-06 | 2012-01-12 | 66 | 516d |  |  | Electronics Design Engineer; Electronics Technician; Mechanical Assembly Technician; Mechanical Designer (monthly); Electrical Design Engineer | 10640h | 1,125,350.24 |
| 68 | 1.3.5 | **Collimation** |  | 110d | 2011-03-01 | 2011-08-01 |  | 634d |  |  |  | 3696h | 398,511.52 |
| 69 | 1.3.5.1 | 400MeV Collimation Labor placeholder |  | 110d | 2011-03-01 | 2011-08-01 |  | 634d |  | start no earlier than 2011-03-01 | Accelerator Physicist Experimental; Mechanical Design Engineer (monthly); Mechanical Assembly Technician; Electrical Design Engineer [60%]; Electronics Technician [60%] | 3696h | 398,511.52 |
| 70 | 1.4 | **BOOSTER** |  | 783d? | 2011-01-05 | 2014-01-03 |  | 0d |  |  |  | 110484h | 19,689,474.84 |
| 71 | 1.4.4 | Booster Gradient Magnets |  | 260d | 2011-10-14 | 2012-10-11 |  | 321d |  | start no earlier than 2011-10-14 | Mechanical Design Engineer (monthly) [50%]; Mechanical Drafter [60%]; Mechanical Assembly Technician | 4368h | 412,702.24 |
| 72 | 1.4.30 | **Booster Controls** |  | 243d | 2012-10-15 | 2013-09-18 |  | 77d |  |  |  | 8748h | 1,625,546.84 |
| 73 | 1.4.30.1 | Booster Controls Procurement | milestone | 0d | 2012-10-15 | 2012-10-15 |  | 77d | 0d | start no earlier than 2012-10-15 |  |  | 500,000 |
| 74 | 1.4.30.2 | Booster Controls Labor |  | 243d | 2012-10-15 | 2013-09-18 | 73 | 77d |  |  | Control System Engineer (monthly) [250%]; Electronics Design Engineer [200%] | 8748h | 1,125,546.84 |

Notes:
- 51: Viability
- 54: Flux Doubling Task
- 56: Flux Doubling Task / Text1: took out controls procurement because linac controls procurement is in line 47
- 57: Text1: added in a labor placeholder
- 58: Flux Doubling Task
- 59: Flux Doubling Task
- 60: Flux Doubling Task
- 61: Flux Doubling Task
- 65: Text1: made this match linac structure
- 69: Flux Doubling Task
- 72: Text1: made this match linac structure

| ID | WBS | Task | Type | Duration | Start | Finish | Predecessors | Total slack | Free slack | Constraint | Resources | Work | Cost |
| --- | --- | --- | --- | --- | --- | --- | --- | --- | --- | --- | --- | --- | --- |
| 75 | 1.4.6 | **Booster RF Solid State RF** |  | 484d? | 2011-01-05 | 2012-11-12 |  | 299d |  |  |  | 19344h | 5,489,819.2 |
| 76 | 1.4.6.5 | **Modulators** |  | 260d | 2011-11-15 | 2012-11-12 |  | 299d | 0d |  |  | 6656h | 1,593,873.28 |
| 77 | 1.4.6.5.1 | Modulators procurement | milestone | 0d | 2011-11-15 | 2011-11-15 |  | 559d |  | start no earlier than 2011-11-15 |  |  | 1,000,000 |
| 78 | 1.4.6.5.2 | Modulators work |  | 260d | 2011-11-15 | 2012-11-12 |  | 299d |  | start no earlier than 2011-11-15 | Electrical Design Engineer [120%]; Electrical Technician [200%] | 6656h | 593,873.28 |
| 79 | 1.4.6.6 | **Power amplifiers** |  | 260d | 2011-11-01 | 2012-10-29 |  | 309d |  |  |  | 6448h | 1,692,683.52 |
| 80 | 1.4.6.6.1 | Power amplifiers procurement | milestone | 0d | 2011-11-01 | 2011-11-01 |  | 569d |  | start no earlier than 2011-11-01 |  |  | 1,100,000 |
| 81 | 1.4.6.6.2 | Power amplifiers work |  | 260d | 2011-11-01 | 2012-10-29 |  | 309d |  | start no earlier than 2011-11-01 | RF Design Engineer [110%]; Electrical Technician [200%] | 6448h | 592,683.52 |
| 82 | 1.4.6.10 | **Solid State Driver modules** |  | 260d | 2011-01-05 | 2012-01-03 |  | 523d |  |  |  | 6240h | 1,803,262.4 |
| 83 | 1.4.6.10.2 | Solid State Driver modules work |  | 260d | 2011-01-05 | 2012-01-03 |  | 523d |  |  | RF Design Engineer; Electrical Assembly Technician; Electrical Technician Supervisor (monthly) | 6240h | 603,262.4 |
| 84 | 1.4.6.10.1 | Solid State Driver modules procurement | milestone | 0d | 2011-10-14 | 2011-10-14 |  | 581d |  | start no earlier than 2011-10-14 |  |  | 1,200,000 |
| 85 | 1.4.6.9 | FY 11 fund expenditure |  | 60d | 2011-02-28 | 2011-05-20 |  | 685d |  | start no earlier than 2011-02-28 |  |  | 200,000 |
| 86 | 1.4.6.8 | Installation |  | 100d? | 2012-06-26 | 2012-11-12 | 76FF | 299d |  | start no earlier than 2012-03-01 |  |  | 200,000 |
| 87 | 1.4.7 | Booster Collimator System Procurement | milestone | 0d | 2012-10-15 | 2012-10-15 |  | 320d |  | start no earlier than 2012-10-15 |  |  | 1,500,000 |
| 88 | 1.4.8 | **Booster Vacuum** |  | 463d | 2011-01-05 | 2012-10-15 |  | 320d |  |  |  | 8800h | 800,808 |
| 89 | 1.4.8.1 | Booster Vacuum equipment order placed | milestone | 0d | 2012-10-15 | 2012-10-15 |  | 320d |  | start no earlier than 2012-10-15 |  |  | 124,000 |
| 90 | 1.4.8.2 | Booster Vacuum Labor |  | 275d | 2011-01-05 | 2012-01-24 |  | 508d |  |  | Mechanical Drafter; Mechanical Design Engineer (monthly); Mechanical Assembly Technician [200%] | 8800h | 676,808 |
| 91 | 1.4.14 | **Booster RF Cavities and Tuners** |  | 318d | 2011-01-05 | 2012-03-23 |  | 465d |  |  |  | 22352h | 2,691,588.16 |
| 92 | 1.4.14.7 | Fabricate and assemble one spare cavity |  | 100d | 2011-01-05 | 2011-05-24 |  | 683d |  |  | RF Design Engineer [50%]; Mechanical Assembly Technician [200%] | 2000h | 153,536 |
| 93 | 1.4.14.8 | Perform pulse repetition rate heating tests on one ‘standard’ cavity | milestone | 0d | 2011-01-05 | 2011-01-05 |  | 783d |  |  |  |  |  |
| 94 | 1.4.14.9 | Inspection, cleaning, and perform thorough maintenance on all cavities | milestone | 0d | 2011-01-05 | 2011-01-05 |  | 783d |  |  |  |  |  |
| 95 | 1.4.14.4 | Booster RF Cavity Tuners Procurement | milestone | 0d | 2011-10-14 | 2011-10-14 |  | 581d |  | start no earlier than 2011-10-14 |  |  | 893,000 |
| 96 | 1.4.14.6 | Booster RF Cavity Tuners Labor |  | 318d | 2011-01-05 | 2012-03-23 |  | 465d |  |  | Electrical Design Engineer [200%]; Electrical Technician [300%]; Mechanical Assembly Technician [300%] | 20352h | 1,645,052.16 |
| 97 | 1.4.32 | **Booster RF Anode Supplies** |  | 583d | 2011-01-05 | 2013-04-01 |  | 200d |  |  |  | 2400h | 1,085,588 |
| 98 | 1.4.32.1 | Booster RF Anode Supplies Procurement | milestone | 0d | 2013-04-01 | 2013-04-01 |  | 200d |  | start no earlier than 2013-04-01 |  |  | 860,000 |
| 99 | 1.4.32.2 | Booster RF Anode Supplies Labor |  | 150d | 2011-01-05 | 2011-08-02 |  | 633d |  |  | Electrical Design Engineer; Electrical Technician | 2400h | 225,588 |

Notes:
- 79: $$ at start to buy tubes
- 95: include line item/name for the labor portion
- 98: include line item/name for the labor portion

| ID | WBS | Task | Type | Duration | Start | Finish | Total slack | Constraint | Resources | Work | Cost |
| --- | --- | --- | --- | --- | --- | --- | --- | --- | --- | --- | --- |
| 100 | 1.4.33 | **Booster RF Bias Supplies** |  | 463d | 2011-01-05 | 2012-10-15 | 320d |  |  | 2400h | 575,588 |
| 101 | 1.4.33.1 | Booster RF Bias Supplies Procurement | milestone | 0d | 2012-10-15 | 2012-10-15 | 320d | start no earlier than 2012-10-15 |  |  | 350,000 |
| 102 | 1.4.33.2 | Booster RF Bias Supplies Labor |  | 150d | 2011-01-05 | 2011-08-02 | 633d |  | Electrical Design Engineer; Electrical Technician | 2400h | 225,588 |
| 103 | 1.4.36 | **Booster RF Test Stand** |  | 202d | 2011-01-05 | 2011-10-14 | 581d |  |  | 2272h | 724,644 |
| 104 | 1.4.36.1 | Booster RF Test Stand Procurement | milestone | 0d | 2011-10-14 | 2011-10-14 | 581d | start no earlier than 2011-10-14 |  |  | 500,000 |
| 105 | 1.4.36.2 | Booster RF Test Stand Labor |  | 142d | 2011-01-05 | 2011-07-21 | 641d |  | RF Design Engineer; Electrical Technician | 2272h | 224,644 |
| 106 | 1.4.38 | **Beam Diagnostics** |  | 520d | 2011-01-05 | 2013-01-02 | 263d |  |  | 10640h | 1,375,350.24 |
| 107 | 1.4.38.1 | Beam Diagnostics Procurement | milestone | 0d | 2013-01-02 | 2013-01-02 | 263d | start no earlier than 2013-01-02 |  |  | 250,000 |
| 108 | 1.4.38.2 | Beam Diagnostics Labor |  | 266d | 2011-01-05 | 2012-01-11 | 517d |  | Electronics Design Engineer; Electronics Technician; Mechanical Assembly Technician; Mechanical Designer (monthly); Electrical Design Engineer | 10640h | 1,125,350.24 |
| 109 | 1.4.16 | **Extraction Notch Cogging** |  | 150d | 2011-01-05 | 2011-08-02 | 633d |  |  | 6600h | 711,654 |
| 110 | 1.4.16.1 | Extraction Notch Cogging labor placeholder |  | 150d | 2011-01-05 | 2011-08-02 | 633d |  | Accelerator Physicist Experimental; Accelerator Systems Specialist; Electrical Design Engineer; Electronics Technician [150%]; Mechanical Assembly Technician | 6600h | 711,654 |
| 111 | 1.4.17 | **Injection Painting** |  | 100d | 2013-01-02 | 2013-05-21 | 163d |  |  | 800h | 102,532 |
| 112 | 1.4.17.1 | Injection Painting Labor Placeholder |  | 100d | 2013-01-02 | 2013-05-21 | 163d | start no earlier than 2013-01-02 | Accelerator Physicist Theory [50%]; Electrical Design Engineer [50%] | 800h | 102,532 |
| 113 | 1.4.18 | **Collimation** |  | 263d | 2013-01-02 | 2014-01-03 | 0d |  |  | 14728h | 1,699,527.04 |
| 114 | 1.4.18.2 | Booster Collimation Labor Placeholder |  | 263d | 2013-01-02 | 2014-01-03 | 0d | start no earlier than 2013-01-02 | Accelerator Physicist Theory; Accelerator Physicist Experimental; Electrical Design Engineer; Mechanical Design Engineer (monthly) [150%]; Mechanical Designer (monthly); Mechanical Systems Technician; Control System Engineer (monthly) [50%] | 14728h | 1,699,527.04 |
| 115 | 1.4.23 | **Aperture Improvements** |  | 168d | 2011-01-05 | 2011-08-26 | 615d |  |  | 4032h | 500,277.12 |
| 116 | 1.4.23.1 | Aperture Improvements Labor placeholder |  | 168d | 2011-01-05 | 2011-08-26 | 615d |  | Accelerator Physicist Experimental; Accelerator Physicist Theory; Mechanical Systems Technician [50%]; Mechanical Design Engineer (monthly) [50%] | 4032h | 500,277.12 |
| 117 | 1.4.24 | **Lattice Improvements** |  | 125d | 2011-01-05 | 2011-06-28 | 658d |  |  | 3000h | 393,850 |
| 118 | 1.4.24.1 | Lattice Improvements Labor Placeholder |  | 125d | 2011-01-05 | 2011-06-28 | 658d |  | Accelerator Physicist Experimental; Accelerator Physicist Theory; Accelerator Systems Specialist | 3000h | 393,850 |
| 119 | 1.4.21 | Radiation Shielding |  | 1d? | 2011-01-05 | 2011-01-05 | 782d |  |  |  |  |
| 120 | 1.5 | **UTILITIES** |  | 584d | 2011-01-05 | 2013-04-02 | 199d |  |  | 10320h | 3,238,456.48 |
| 121 | 1.5.6 | **Linac Power Distribution Systems** |  | 584d | 2011-01-05 | 2013-04-02 | 199d |  |  | 4984h | 1,551,059.2 |
| 122 | 1.5.6.4 | **Linac House Power Transformers** |  | 261d | 2012-04-02 | 2013-04-02 | 199d |  |  |  | 675,000 |
| 123 | 1.5.6.4.1 | FY12 Procurement | milestone | 0d | 2012-04-02 | 2012-04-02 | 460d | start no earlier than 2012-04-02 |  |  | 225,000 |
| 124 | 1.5.6.4.2 | FY13 Procurement | milestone | 0d | 2013-04-02 | 2013-04-02 | 199d | start no earlier than 2013-04-02 |  |  | 450,000 |

Notes:
- 101: include line item/name for the labor portion
- 104: include line item/name for the labor portion

| ID | WBS | Task | Type | Duration | Start | Finish | Total slack | Constraint | Resources | Work | Cost |
| --- | --- | --- | --- | --- | --- | --- | --- | --- | --- | --- | --- |
| 125 | 1.5.6.5 | **Linac Breaker Panels** |  | 260d | 2012-04-02 | 2013-04-01 | 200d |  |  |  | 345,000 |
| 126 | 1.5.6.5.1 | FY12 Procurement | milestone | 0d | 2012-04-02 | 2012-04-02 | 460d | start no earlier than 2012-04-02 |  |  | 115,000 |
| 127 | 1.5.6.5.2 | FY13 Procurement | milestone | 0d | 2013-04-01 | 2013-04-01 | 200d | start no earlier than 2013-04-01 |  |  | 230,000 |
| 128 | 1.5.6.6 | Linac Motor Control Centers Procurement | milestone | 0d | 2012-04-02 | 2012-04-02 | 460d | start no earlier than 2012-04-02 |  |  | 60,000 |
| 129 | 1.5.6.7 | Linac Utilities Labor |  | 178d | 2011-01-05 | 2011-09-09 | 605d |  | Electrical Technician Supervisor (monthly) [150%]; Electrical Designer (weekly) [200%] | 4984h | 471,059.2 |
| 130 | 1.5.2 | **Booster Power Distribution Systems** |  | 583d | 2011-01-05 | 2013-04-01 | 200d |  |  | 3480h | 1,004,095.2 |
| 131 | 1.5.1.10 | Booster House Power Transformers Procurement | milestone | 0d | 2013-04-01 | 2013-04-01 | 200d | start no earlier than 2013-04-01 |  |  | 446,000 |
| 132 | 1.5.1.9 | Booster Motor Control Centers Procurement | milestone | 0d | 2013-04-01 | 2013-04-01 | 200d | start no earlier than 2013-04-01 |  |  | 240,000 |
| 133 | 1.5.2.11 | Booster Utilities Labor |  | 145d | 2011-01-05 | 2011-07-26 | 638d |  | Electrical Technician Supervisor (monthly); Electrical Designer (weekly) [200%] | 3480h | 318,095.2 |
| 134 | 1.5.8 | **Booster LCW** |  | 202d | 2011-01-05 | 2011-10-14 | 581d |  |  | 1856h | 633,302.08 |
| 135 | 1.5.8.1 | 95 LCW System Procurement | milestone | 0d | 2011-10-14 | 2011-10-14 | 581d | start no earlier than 2011-10-14 |  |  | 465,000 |
| 136 | 1.5.8.2 | LCW Labor |  | 116d | 2011-01-05 | 2011-06-15 | 667d |  | Mechanical Design Engineer (monthly); Mechanical Systems Technician | 1856h | 168,302.08 |
| 137 | 1.5.4 | Booster Sumps Procurement | milestone | 0d | 2011-10-14 | 2011-10-14 | 581d | start no earlier than 2011-10-14 |  |  | 50,000 |
| 138 | 1.7 | Accelerator Shutdown |  | 262d? | 2012-03-01 | 2013-03-01 | 220d | finish no earlier than 2013-03-01 |  |  |  |
